# Desarrollo MyWaySoftware

Schedule from MS Project, 2015-06-01 to 2015-09-14, status date 2015-05-31, costs in $, A marks actual dates.
Software Development

## Calendars

- Standard: Mon-Fri 08:00-12:00, 13:00-17:00; Sat-Sun off.

## Resources

| Resource | Group | Rate |
| --- | --- | --- |
| Andrés Cerdas | Dev | 50 |
| Jesé Molina | Dev | 50 |
| Carmen Rojas | PMO | 50 |
| Roberto Campos | Test | 50 |
| Analista de Pruebas | Test | 50 |

## Schedule

| ID | WBS | Task | Type | Duration | Start | Finish | Predecessors | Complete | Remaining | Baseline start | Baseline finish | Baseline duration | Total slack | Free slack | Constraint | Deadline | Resources | Work | Actual work | Cost | Baseline cost | Actual cost |
| --- | --- | --- | --- | --- | --- | --- | --- | --- | --- | --- | --- | --- | --- | --- | --- | --- | --- | --- | --- | --- | --- | --- |
| 1 | 1 | **Análisis de Requerimientos** |  | 16d | 2015-06-01 A | 2015-06-22 |  | 97% | 0.46d | 2015-06-01 | 2015-06-22 | 16d | 0d |  |  |  |  | 66h | 62h | 3,300 | 3,300 | 3,100 |
| 2 | 1.1 | Realizar Análisis de Requerimientos |  | 3.75d | 2015-06-01 A | 2015-06-04 |  | 89% | 0.42d | 2015-06-01 | 2015-06-04 | 3.75d | 1.25d |  | finish no later than 2015-06-06 |  | Carmen Rojas [75%] | 24h | 20h | 1,200 | 1,200 | 1,000 |
| 3 | 1.2 | Realizar Especificaciones del Software |  | 6d | 2015-06-08 A | 2015-06-15 A | 2 | 100% |  | 2015-06-08 | 2015-06-15 | 6d |  |  |  |  | Andrés Cerdas [62.5%] | 24h | 24h | 1,200 | 1,200 | 1,200 |
| 4 | 1.3 | Desarrollar Presupuesto |  | 1.8d | 2015-06-15 A | 2015-06-16 A | 3 | 100% |  | 2015-06-15 | 2015-06-16 | 1.8d |  |  |  |  | Carmen Rojas [75%] | 10h | 10h | 500 | 500 | 500 |
| 5 | 1.4 | Realizar Cronograma de Desarrollo |  | 3d | 2015-06-17 A | 2015-06-22 A | 4 | 100% |  | 2015-06-17 | 2015-06-22 | 3d |  |  |  |  | Andrés Cerdas [50%] | 8h | 8h | 400 | 400 | 400 |
| 6 | 2 | Fin Proceso de Análisis | milestone | 0d | 2015-06-22 A | 2015-06-22 A | 5 | 100% |  | 2015-06-22 | 2015-06-22 | 0d |  |  |  | 2015-06-22 |  |  |  |  |  |  |
| 7 | 3 | **Diseño** |  | 13d | 2015-06-23 A | 2015-07-09 A |  | 100% |  | 2015-06-23 | 2015-07-09 | 13d |  |  |  |  |  | 69h | 69h | 3,650 | 3,650 | 3,650 |
| 8 | 3.1 | Desarrollar Especificaciones Funcionales |  | 9d | 2015-06-23 A | 2015-07-06 A | 6 | 100% |  | 2015-06-23 | 2015-07-06 | 9d |  |  | start no earlier than 2015-06-15 |  | Jesé Molina [62.5%] | 37h | 37h | 1,850 | 1,850 | 1,850 |
| 9 | 3.2 | Desarrollar Prototipo |  | 3d | 2015-07-07 A | 2015-07-09 A | 8 | 100% |  | 2015-07-07 | 2015-07-09 | 3d |  |  |  |  | Jesé Molina | 32h | 32h | 1,800 | 1,800 | 1,800 |
| 10 | 4 | Fin Proceso de Diseño | milestone | 0d | 2015-07-09 A | 2015-07-09 A | 9 | 100% |  | 2015-07-09 | 2015-07-09 | 0d |  |  |  | 2015-07-09 |  |  |  |  |  |  |
| 11 | 5 | **Desarrollo** |  | 24d | 2015-07-10 A | 2015-08-12 |  | 18% | 19.64d | 2015-07-10 | 2015-08-12 | 24d | 22d |  |  |  |  | 248h | 32h | 12,400 | 12,400 | 1,600 |
| 12 | 5.1 | Identificar Parámetros de Diseño |  | 1d | 2015-07-10 A | 2015-07-10 A | 10 | 100% |  | 2015-07-10 | 2015-07-10 | 1d |  |  |  |  | Jesé Molina [50%] | 4h | 4h | 200 | 200 | 200 |
| 13 | 5.2 | Desarrollar Programación |  | 21d | 2015-07-13 A | 2015-08-10 | 12 | 14% | 18d | 2015-07-13 | 2015-08-10 | 21d | 24d | 0d |  |  | Jesé Molina | 156h | 12h | 7,800 | 7,800 | 600 |
| 14 | 5.3 | Realizar Pruebas del Software - Programador |  | 22d | 2015-07-14 A | 2015-08-12 | 13SS+1d | 18% | 18d | 2015-07-14 | 2015-08-12 | 22d | 5d | 0d |  |  | Analista de Pruebas [50%] | 88h | 16h | 4,400 | 4,400 | 800 |
| 15 | 6 | Fin Proceso de Desarrollo | milestone | 0d | 2015-08-12 | 2015-08-12 | 14 |  |  | 2015-08-12 | 2015-08-12 | 0d | 5d | 0d |  | 2015-08-20 |  |  |  |  |  |  |
| 16 | 7 | **Pruebas** |  | 17d | 2015-08-13 | 2015-09-04 |  |  |  | 2015-08-13 | 2015-09-04 | 17d | 5d |  |  |  |  | 116h |  | 5,800 | 5,800 |  |
| 17 | 7.1 | Realizar Pruebas por Módulos |  | 5d | 2015-08-13 | 2015-08-19 | 15 |  |  | 2015-08-13 | 2015-08-19 | 5d | 5d | 0d | start no earlier than 2015-08-11 |  | Roberto Campos | 40h |  | 2,000 | 2,000 |  |
| 18 | 7.2 | Realizar Pruebas Integrales |  | 2d | 2015-08-20 | 2015-08-21 | 17 |  |  | 2015-08-20 | 2015-08-21 | 2d | 5d | 0d |  |  | Analista de Pruebas | 16h |  | 800 | 800 |  |
| 19 | 7.3 | Identificar Anomalías a las Especificaciones del Software |  | 3d | 2015-08-24 | 2015-08-26 | 18 |  |  | 2015-08-24 | 2015-08-26 | 3d | 5d | 0d |  |  | Analista de Pruebas | 24h |  | 1,200 | 1,200 |  |
| 20 | 7.4 | Realizar Ajustes |  | 5d | 2015-08-27 | 2015-09-02 | 19 |  |  | 2015-08-27 | 2015-09-02 | 5d | 5d | 0d |  |  | Jesé Molina [50%] | 20h |  | 1,000 | 1,000 |  |
| 21 | 7.5 | Realizar Pruebas a Ajustes Realizados |  | 2d | 2015-09-03 | 2015-09-04 | 20 |  |  | 2015-09-03 | 2015-09-04 | 2d | 5d |  |  |  | Roberto Campos | 16h |  | 800 | 800 |  |
| 22 | 8 | Fin Proceso de Pruebas | milestone | 0d | 2015-09-14 | 2015-09-14 | 21 |  |  | 2015-09-14 | 2015-09-14 | 0d | 0d |  | must finish on 2015-09-14 |  |  |  |  |  |  |  |
