# Cinema Paraíso

Schedule from MS Project, 2015-09-01 to 2018-12-04, costs in $, A marks actual dates.

## Calendars

- Standard: Mon-Fri 08:00-12:00, 13:00-17:00; Sat-Sun off.
- Evening Shoot: Mon-Fri 17:00-23:00; Sat-Sun off.

## Resources

| Resource | Group | Unit | Rate | Cost per use |
| --- | --- | --- | --- | --- |
| Cámara de 16 mm | Equipo |  | 7.5 |  |
| Película de 16 mm | Laboratorio | 100 metros | 25 |  |
| Foco de 500 watios | Equipo |  | 2.5 |  |
| Ana Herrera | Creativos |  | 18.75 |  |
| Trípode de cámara | Equipo |  |  |  |
| Cesar Palacios | Producción |  | 22.5 |  |
| Grúa | Equipo |  |  |  |
| Daniel Rojas | Creativos |  | 18.75 |  |
| Joel Navas | Creativos |  | 18.75 |  |
| Dolly | Equipo |  |  |  |
| Douglas Hernandez | Producción |  | 19.2 |  |
| Laboratorio de edición | Laboratorio |  | 31.25 | 25 |
| Electricista | Auxiliares |  | 28 |  |
| Erick Mata | Producción |  | 18.5 |  |
| Erick Mora | Creativos |  | 18.75 |  |
| Floria Villegas | Producción |  | 25 |  |
| Francisco Lepiz | Auxiliares |  | 17 |  |
| Joaquin Vargas | Producción |  | 21.75 |  |
| Jose Urcuyo | Creativos |  | 9.38 |  |
| Jose Navas | Producción |  | 21.75 |  |
| Jonathan Casas | Producción |  | 25 |  |
| Matias Blanco | Creativos |  | 18.75 |  |
| Selma Mitchell | Creativos |  | 16 |  |
| Olman Acuna | Producción |  | 20 | 100 |
| Sandra Palacios | Auxiliares |  | 17 |  |
| Pablo Solera | Producción |  | 16.4 |  |
| Linsday Carranza | Producción |  | 27 |  |
| Emerson Parajeles | Producción |  | 16 |  |
| Andres Avalos | Producción |  | 25 |  |
| Pablo Madriz | Auxiliares |  | 27 |  |
| Yaz Solano | Auxiliares |  | 21 |  |
| Oscar Mendez | Producción |  | 20.5 |  |
| Patricia Monge | Producción |  | 15 |  |
| Paul Rodriguez | Producción |  | 28.12 |  |
| Reflector | Equipo |  |  |  |
| Ricardo Arias | Producción |  | 18.5 |  |
| Mauricio Herrera | Producción |  | 21 |  |
| Cuty Monge | Producción |  | 22 |  |
| Susan Boyle | Creativos |  | 15 |  |
| Teodoro Bravo | Auxiliares |  | 18 |  |
| Tommy Torres | Auxiliares |  | 18 |  |
| Servicio de Catering | Gastos |  |  |  |
| Viaticos | Gastos |  |  |  |

## Schedule

| ID | WBS | Task | Type | Duration | Start | Finish | Predecessors | Complete | Remaining | Total slack | Constraint | Deadline | Resources | Work | Actual work | Cost | Actual cost | Personal | Location |
| --- | --- | --- | --- | --- | --- | --- | --- | --- | --- | --- | --- | --- | --- | --- | --- | --- | --- | --- | --- |
| 1 | 1 | **Preproducción** |  | 702.88d | 2015-09-01 A | 2018-05-10 |  | 92% | 58.61d | 0.12d |  |  |  | 8960h | 7812h | 201,720 | 174,490 |  |  |
| 2 | 1.1 | Revisión del guión literario |  | 650d | 2015-09-01 A | 2018-02-26 A |  | 100% |  |  |  |  | Cuty Monge [50%]; Cesar Palacios | 7792h | 7792h | 174,020 | 174,020 |  |  |
| 3 | 1.2 | División y planificación del guión literario |  | 1w | 2018-02-21 A | 2018-03-02 | 2 | 25% | 0.75w | 0d |  |  | Cuty Monge; Jonathan Casas | 80h | 20h | 1,880 | 470 |  |  |
| 4 | 1.3 | Desarrollo del guión técnico |  | 1.07mo | 2018-03-02 | 2018-04-04 | 3 |  |  | 0d |  |  | Cuty Monge; Pablo Solera; Jonathan Casas | 480h |  | 10,144 |  |  |  |
| 5 | 1.4 | Búsqueda de exteriores |  | 2w | 2018-04-05 | 2018-04-18 | 4 |  |  | 0.12d |  |  | Jose Navas; Joaquin Vargas; Pablo Madriz; Viaticos [0.1%] | 240h |  | 6,640 |  |  |  |
| 6 | 1.5 | Selección de exteriores |  | 1.05w | 2018-04-19 | 2018-04-26 | 5 |  |  | 0d |  |  | Cuty Monge; Cesar Palacios; Pablo Madriz | 120h |  | 2,860 |  |  |  |
| 7 | 1.6 | Realización de pruebas a actores |  | 1.05w | 2018-04-26 | 2018-05-03 | 6 |  |  | 0d |  |  | Cesar Palacios; Cuty Monge; Douglas Hernandez [50%]; Servicio de Catering [0.1%] | 100h |  | 2,664 |  |  |  |
| 8 | 1.7 | Solicitud de permisos de rodaje |  | 1w | 2018-05-03 | 2018-05-10 | 7 |  |  | 0d |  |  | Pablo Solera | 40h |  | 1,156 |  |  |  |
| 9 | 1.8 | Reserva de equipo de rodaje |  | 3d | 2018-05-08 | 2018-05-10 | 8FS-5% |  |  | 0d |  |  | Joaquin Vargas; Erick Mata [50%] | 36h |  | 744 |  |  |  |
| 10 | 1.9 | Reserva de equipo de sonido |  | 3d | 2018-05-08 | 2018-05-10 | 9SS |  |  | 0d |  |  | Erick Mata [50%] | 12h |  | 222 |  |  |  |
| 11 | 1.10 | ¡Preproducción completada! | milestone | 0d | 2018-05-10 | 2018-05-10 | 10 |  |  | 0.12d |  | 2018-11-22 |  |  |  |  |  |  |  |
| 12 | 1.11 | **Reunión de seguimiento** |  | 45.25d | 2015-09-10 | 2015-11-12 |  |  |  | 650.62d |  |  |  | 60h |  | 1,390 |  |  |  |
| 13 | 1.11.1 | Reunión de seguimiento 1 |  | 2h | 2015-09-10 | 2015-09-10 |  |  |  | 695.62d | start no earlier than 2015-09-10 |  | Cesar Palacios; Jonathan Casas; Cuty Monge | 6h |  | 139 |  |  |  |
| 14 | 1.11.2 | Reunión de seguimiento 2 |  | 2h | 2015-09-17 | 2015-09-17 |  |  |  | 690.62d | start no earlier than 2015-09-17 |  | Cesar Palacios; Jonathan Casas; Cuty Monge | 6h |  | 139 |  |  |  |
| 15 | 1.11.3 | Reunión de seguimiento 3 |  | 2h | 2015-09-24 | 2015-09-24 |  |  |  | 685.62d | start no earlier than 2015-09-24 |  | Cesar Palacios; Jonathan Casas; Cuty Monge | 6h |  | 139 |  |  |  |
| 16 | 1.11.4 | Reunión de seguimiento 4 |  | 2h | 2015-10-01 | 2015-10-01 |  |  |  | 680.62d | start no earlier than 2015-10-01 |  | Cesar Palacios; Jonathan Casas; Cuty Monge | 6h |  | 139 |  |  |  |
| 17 | 1.11.5 | Reunión de seguimiento 5 |  | 2h | 2015-10-08 | 2015-10-08 |  |  |  | 675.62d | start no earlier than 2015-10-08 |  | Cesar Palacios; Jonathan Casas; Cuty Monge | 6h |  | 139 |  |  |  |
| 18 | 1.11.6 | Reunión de seguimiento 6 |  | 2h | 2015-10-15 | 2015-10-15 |  |  |  | 670.62d | start no earlier than 2015-10-15 |  | Cesar Palacios; Jonathan Casas; Cuty Monge | 6h |  | 139 |  |  |  |
| 19 | 1.11.7 | Reunión de seguimiento 7 |  | 2h | 2015-10-22 | 2015-10-22 |  |  |  | 665.62d | start no earlier than 2015-10-22 |  | Cesar Palacios; Jonathan Casas; Cuty Monge | 6h |  | 139 |  |  |  |
| 20 | 1.11.8 | Reunión de seguimiento 8 |  | 2h | 2015-10-29 | 2015-10-29 |  |  |  | 660.62d | start no earlier than 2015-10-29 |  | Cesar Palacios; Jonathan Casas; Cuty Monge | 6h |  | 139 |  |  |  |
| 21 | 1.11.9 | Reunión de seguimiento 9 |  | 2h | 2015-11-05 | 2015-11-05 |  |  |  | 655.62d | start no earlier than 2015-11-05 |  | Cesar Palacios; Jonathan Casas; Cuty Monge | 6h |  | 139 |  |  |  |
| 22 | 1.11.10 | Reunión de seguimiento 10 |  | 2h | 2015-11-12 | 2015-11-12 |  |  |  | 650.62d | start no earlier than 2015-11-12 |  | Cesar Palacios; Jonathan Casas; Cuty Monge | 6h |  | 139 |  |  |  |
| 23 | 2 | **Producción** |  | 52.38d | 2018-05-11 | 2018-07-24 | 1 |  |  | 0d |  |  |  | 2243h |  | 47,058.2 |  |  |  |
| 24 | 2.1 | **Escena 7** |  | 4.88d | 2018-05-11 | 2018-05-17 |  |  |  | 0d |  |  |  | 220h |  | 4,718.5 |  |  |  |
| 25 | 2.1.1 | Escena 7: Instalación de decorados |  | 1d | 2018-05-11 | 2018-05-11 |  |  |  | 0d |  |  | Jose Navas; Pablo Madriz; Electricista [50%] | 20h |  | 502 |  |  |  |
| 26 | 2.1.2 | Escena 7: Ensayo |  | 1d | 2018-05-14 | 2018-05-14 | 25 |  |  | 0d |  |  | Cuty Monge; Jose Navas; Paul Rodriguez [50%]; Matias Blanco; Susan Boyle; Joaquin Vargas | 44h |  | 906.5 |  |  |  |
| 27 | 2.1.3 | Escena 7: Rodaje |  | 1d | 2018-05-15 | 2018-05-15 | 26 |  |  | 0d |  |  | Cuty Monge; Jose Navas; Matias Blanco; Susan Boyle; Francisco Lepiz; Sandra Palacios; Teodoro Bravo; Cámara de 16 mm [300%]; Foco de 500 watios [200%]; Selma Mitchell; Yaz Solano; Tommy Torres; Joaquin Vargas; Trípode de cámara; Película de 16 mm [5 100 metros] | 136h |  | 2,808 |  | Richard, Store clerk #1, Store clerk #2 | Grocery store |
| 28 | 2.1.4 | Escena 7: Montaje |  | 1d | 2018-05-16 | 2018-05-16 | 27 |  |  | 0d |  |  | Jose Navas; Pablo Madriz; Electricista [50%] | 20h |  | 502 |  |  |  |
| 29 | 2.1.5 | Escena 7: Reproceso |  | 1d | 2018-05-17 | 2018-05-17 | 28 |  |  | 0.12d |  |  |  |  |  |  |  |  |  |

| ID | WBS | Task | Duration | Start | Finish | Predecessors | Total slack | Free slack | Constraint | Calendar | Resources | Work | Cost | Personal | Location |
| --- | --- | --- | --- | --- | --- | --- | --- | --- | --- | --- | --- | --- | --- | --- | --- |
| 30 | 2.2 | **Escena 3** | 4d | 2018-05-17 | 2018-05-23 | 24 | 0.12d | 0d |  |  |  | 268h | 5,330.8 |  |  |
| 31 | 2.2.1 | Escena 3: Instalación de decorados | 1d | 2018-05-17 | 2018-05-18 |  | 0d |  | start no earlier than 2011-11-25 |  | Jose Navas; Pablo Madriz; Electricista | 24h | 614 |  |  |
| 32 | 2.2.2 | Escena 3: Ensayo | 1d | 2018-05-18 | 2018-05-21 | 31 | 0d |  |  |  | Cuty Monge; Jose Navas; Erick Mora; Jose Urcuyo; Ana Herrera; Matias Blanco; Joaquin Vargas | 56h | 1,049 |  |  |
| 33 | 2.2.3 | Escena 3: Rodaje | 1d | 2018-05-21 | 2018-05-22 | 32 | 0d |  |  |  | Cuty Monge; Jose Navas; Erick Mora; Jose Urcuyo; Ana Herrera; Matias Blanco; Tommy Torres; Yaz Solano; Douglas Hernandez [50%]; Sandra Palacios; Cámara de 16 mm [200%]; Foco de 500 watios [400%]; Dolly; Francisco Lepiz; Joaquin Vargas; Teodoro Bravo; Trípode de cámara; Película de 16 mm [5 100 metros] | 164h | 3,053.8 | Man on street, Richard | Street corner |
| 34 | 2.2.4 | Escena 3: Montaje | 1d | 2018-05-22 | 2018-05-23 | 33 | 0d |  |  |  | Jose Navas; Pablo Madriz; Electricista | 24h | 614 |  |  |
| 35 | 2.2.5 | Escena 3: Reproceso | 1d | 2018-05-23 | 2018-05-23 | 33 | 0.12d |  |  |  |  |  |  |  |  |
| 36 | 2.3 | **Escena 1** | 6d | 2018-05-23 | 2018-05-31 | 30 | 0.12d | 0d |  |  |  | 324h | 7,469.8 |  |  |
| 37 | 2.3.1 | Escena 1: Instalación de decorados | 3d | 2018-05-23 | 2018-05-28 |  | 0d |  |  |  | Jose Navas; Pablo Madriz; Electricista [200%] | 96h | 2,514 |  |  |
| 38 | 2.3.2 | Escena 1: Ensayo | 1d | 2018-05-28 | 2018-05-29 | 37 | 0d |  |  |  | Cuty Monge; Jose Navas; Paul Rodriguez [50%]; Joel Navas; Erick Mora; Susan Boyle; Joaquin Vargas | 52h | 1,056.5 |  |  |
| 39 | 2.3.3 | Escena 1: Rodaje | 1d | 2018-05-29 | 2018-05-30 | 38 | 0d |  |  |  | Cuty Monge; Jose Navas; Paul Rodriguez [50%]; Joel Navas; Erick Mora; Susan Boyle; Tommy Torres; Francisco Lepiz; Yaz Solano; Douglas Hernandez [50%]; Sandra Palacios; Teodoro Bravo; Cámara de 16 mm [300%]; Foco de 500 watios; Joaquin Vargas; Dolly; Trípode de cámara; Película de 16 mm [5 100 metros] | 144h | 3,061.3 | Garth, Man on street, Store clerk #1 | Street corner |
| 40 | 2.3.4 | Escena 1: Montaje | 1d | 2018-05-30 | 2018-05-31 | 39 | 0d |  |  |  | Jose Navas; Pablo Madriz; Electricista [200%] | 32h | 838 |  |  |
| 41 | 2.3.5 | Escena 1: Reproceso | 1d | 2018-05-31 | 2018-05-31 | 39 | 0.12d |  |  |  |  |  |  |  |  |
| 42 | 2.4 | **Escena 2** | 5d | 2018-05-31 | 2018-06-07 | 36 | 0.12d | 0d |  |  |  | 216h | 4,421.6 |  |  |
| 43 | 2.4.1 | Escena 2: Instalación de decorados | 1d | 2018-05-31 | 2018-06-01 |  | 0d |  |  |  | Jose Navas; Pablo Madriz; Electricista | 24h | 614 |  |  |
| 44 | 2.4.2 | Escena 2: Ensayo | 1d | 2018-06-01 | 2018-06-04 | 43 | 0d |  |  |  | Cuty Monge; Douglas Hernandez [50%]; Joel Navas; Ana Herrera; Joaquin Vargas | 36h | 726.8 |  |  |
| 45 | 2.4.3 | Escena 2: Rodaje | 1d | 2018-06-04 | 2018-06-05 | 44 | 0.5d | 0.12d |  | Evening Shoot | Cuty Monge; Douglas Hernandez [50%]; Ana Herrera; Tommy Torres; Francisco Lepiz; Sandra Palacios; Teodoro Bravo; Cámara de 16 mm [200%]; Foco de 500 watios [300%]; Joaquin Vargas; Joel Navas; Trípode de cámara; Grúa; Dolly; Película de 16 mm [5 100 metros] | 132h | 2,466.8 | Garth, Shelly | Shelly's living room |
| 46 | 2.4.4 | Escena 2: Montaje | 1d | 2018-06-06 | 2018-06-06 | 45 | 0d |  |  |  | Jose Navas; Pablo Madriz; Electricista | 24h | 614 |  |  |
| 47 | 2.4.5 | Escena 2: Reproceso | 1d | 2018-06-07 | 2018-06-07 | 46 | 0.12d |  |  |  |  |  |  |  |  |
| 48 | 2.5 | **Escena 5** | 6d | 2018-06-07 | 2018-06-15 | 42 | 0.12d | 0d |  |  |  | 288h | 5,925.8 |  |  |
| 49 | 2.5.1 | Escena 5: Instalación de decorados | 3d | 2018-06-07 | 2018-06-12 |  | 0d |  |  |  | Jose Navas; Pablo Madriz | 48h | 1,170 |  |  |
| 50 | 2.5.2 | Escena 5: Ensayo | 1d | 2018-06-12 | 2018-06-13 | 49 | 0d |  |  |  | Cuty Monge; Jose Navas; Erick Mora; Joel Navas; Susan Boyle; Daniel Rojas; Ana Herrera; Joaquin Vargas [50%] | 60h | 1,157 |  |  |
| 51 | 2.5.3 | Escena 5: Rodaje | 1d | 2018-06-13 | 2018-06-14 | 50 | 0d |  |  |  | Cuty Monge; Jose Navas; Erick Mora; Joel Navas; Susan Boyle; Daniel Rojas; Ana Herrera; Tommy Torres; Francisco Lepiz; Yaz Solano; Douglas Hernandez [50%]; Sandra Palacios; Teodoro Bravo; Cámara de 16 mm [200%]; Foco de 500 watios [200%]; Grúa; Joaquin Vargas; Trípode de cámara; Dolly; Película de 16 mm [5 100 metros] | 164h | 3,208.8 | Man on street, Garth, Old man, Shelly | Street corner |
| 52 | 2.5.4 | Escena 5: Montaje | 1d | 2018-06-14 | 2018-06-15 | 51 | 0d |  |  |  | Jose Navas; Pablo Madriz | 16h | 390 |  |  |
| 53 | 2.5.5 | Escena 5: Reproceso | 1d | 2018-06-15 | 2018-06-15 | 51 | 0.12d |  |  |  |  |  |  |  |  |

| ID | WBS | Task | Duration | Start | Finish | Predecessors | Total slack | Free slack | Resources | Work | Cost | Personal | Location |
| --- | --- | --- | --- | --- | --- | --- | --- | --- | --- | --- | --- | --- | --- |
| 54 | 2.6 | **Escena 6** | 14d | 2018-06-15 | 2018-07-05 | 48 | 0.12d | 0d |  | 524h | 10,604.2 |  |  |
| 55 | 2.6.1 | Escena 6: Instalación de decorados | 6d | 2018-06-15 | 2018-06-25 |  | 0d |  | Jose Navas; Pablo Madriz | 96h | 2,340 |  |  |
| 56 | 2.6.2 | Escena 6: Ensayo | 3d | 2018-06-25 | 2018-06-28 | 55 | 0d |  | Cuty Monge; Jose Navas; Douglas Hernandez [50%]; Paul Rodriguez [50%]; Joel Navas; Susan Boyle; Ana Herrera; Jose Urcuyo; Daniel Rojas; Joaquin Vargas [50%] | 204h | 3,813.9 |  |  |
| 57 | 2.6.3 | Escena 6: Rodaje | 1d | 2018-06-28 | 2018-06-29 | 56 | 0d |  | Cuty Monge; Jose Navas; Douglas Hernandez [50%]; Paul Rodriguez [50%]; Joel Navas; Susan Boyle; Ana Herrera; Jose Urcuyo; Daniel Rojas; Francisco Lepiz; Yaz Solano; Sandra Palacios; Teodoro Bravo; Cámara de 16 mm [300%]; Foco de 500 watios [300%]; Dolly; Grúa; Selma Mitchell; Tommy Torres; Película de 16 mm [5 100 metros] | 176h | 3,280.3 | Garth, Store Clerk #1, Shelly, Old man | Grocery store |
| 58 | 2.6.4 | Escena 6: Montaje | 3d | 2018-06-29 | 2018-07-04 | 57 | 0d |  | Jose Navas; Pablo Madriz | 48h | 1,170 |  |  |
| 59 | 2.6.5 | Escena 6: Reproceso | 1d | 2018-07-05 | 2018-07-05 | 58 | 0.12d |  |  |  |  |  |  |
| 60 | 2.7 | **Escena 8** | 8d | 2018-07-05 | 2018-07-17 | 54 | 0d |  |  | 312h | 6,479.9 |  |  |
| 61 | 2.7.1 | Escena 8: Instalación de decorados | 3d | 2018-07-05 | 2018-07-10 |  | 0d |  | Jose Navas; Pablo Madriz | 48h | 1,170 |  |  |
| 62 | 2.7.2 | Escena 8: Ensayo | 2d | 2018-07-10 | 2018-07-12 | 61 | 0d |  | Cuty Monge; Jose Navas; Douglas Hernandez [50%]; Paul Rodriguez [50%]; Joel Navas; Susan Boyle; Erick Mora; Joaquin Vargas [50%] | 104h | 2,092.6 |  |  |
| 63 | 2.7.3 | Escena 8: Rodaje | 1d | 2018-07-12 | 2018-07-13 | 62 | 0d |  | Cuty Monge; Jose Navas; Douglas Hernandez [50%]; Paul Rodriguez [50%]; Joel Navas; Susan Boyle; Erick Mora; Tommy Torres; Francisco Lepiz; Yaz Solano; Sandra Palacios; Teodoro Bravo; Cámara de 16 mm [200%]; Foco de 500 watios; Dolly [200%]; Trípode de cámara; Grúa; Película de 16 mm [5 100 metros] | 144h | 2,827.3 | Garth, Store clerk #1, Man on street | Street corner |
| 64 | 2.7.4 | Escena 8: Montaje | 1d | 2018-07-13 | 2018-07-16 | 63 | 0d |  | Jose Navas; Pablo Madriz | 16h | 390 |  |  |
| 65 | 2.7.5 | Escena 8: Reproceso | 1d | 2018-07-17 | 2018-07-17 | 64 | 0d |  |  |  |  |  |  |
| 66 | 2.8 | **Escena 4** | 4.5d | 2018-07-17 | 2018-07-24 | 60 | 0d |  |  | 91h | 2,107.6 |  |  |
| 67 | 2.8.1 | Escena 4: Instalación de decorados | 2d | 2018-07-17 | 2018-07-19 |  | 0d |  | Jose Navas; Pablo Madriz | 32h | 780 |  |  |
| 68 | 2.8.2 | Escena 4: Ensayo | 4h | 2018-07-19 | 2018-07-20 | 67 | 0d |  | Cuty Monge; Douglas Hernandez [50%]; Ana Herrera; Matias Blanco; Joaquin Vargas [50%] | 16h | 319.9 |  |  |
| 69 | 2.8.3 | Escena 4: Rodaje | 2h | 2018-07-20 | 2018-07-20 | 68 | 0d |  | Cuty Monge; Douglas Hernandez [50%]; Ana Herrera; Matias Blanco; Francisco Lepiz; Yaz Solano; Sandra Palacios; Cámara de 16 mm [200%]; Foco de 500 watios [200%]; Joaquin Vargas; Teodoro Bravo; Trípode de cámara; Película de 16 mm [5 100 metros] | 27h | 617.7 | Shelly, Richard | Elevator |
| 70 | 2.8.4 | Escena 4: Montaje | 1d | 2018-07-20 | 2018-07-23 | 69 | 0d |  | Jose Navas; Pablo Madriz | 16h | 390 |  |  |
| 71 | 2.8.5 | Escena 4: Reproceso | 1d | 2018-07-23 | 2018-07-24 | 70 | 0.25d |  |  |  |  |  |  |
| 72 | 3 | **Post-producción** | 95.38d | 2018-07-24 | 2018-12-04 | 23 | 0d |  |  | 1628h | 36,662.4 |  |  |
| 73 | 3.1 | Ajustes previos | 9d | 2018-07-24 | 2018-08-06 |  | 0.25d | 0d | Laboratorio de edición; Viaticos [0.2%] | 72h | 3,771 |  |  |
| 74 | 3.2 | Grabación BS previa | 12d | 2018-08-06 | 2018-08-22 | 73 | 0d |  | Joel Navas; Oscar Mendez | 192h | 3,768 |  |  |
| 75 | 3.3 | Edición en papel | 10d | 2018-08-22 | 2018-09-05 | 74 | 0d |  | Cesar Palacios; Pablo Solera; Emerson Parajeles; Ricardo Arias | 320h | 5,872 |  |  |
| 76 | 3.4 | Primera edición | 5d | 2018-09-05 | 2018-09-12 | 75 | 0d |  | Cesar Palacios; Ricardo Arias | 80h | 1,640 |  |  |
| 77 | 3.5 | Ajustes en la edición | 10d | 2018-09-12 | 2018-09-26 | 76 | 0d |  | Cesar Palacios; Ricardo Arias; Emerson Parajeles; Pablo Solera; Laboratorio de edición | 400h | 8,397 |  |  |
| 78 | 3.6 | Presentación a cliente | 1d | 2018-09-26 | 2018-09-27 | 77 | 0.25d | 0d | Cesar Palacios; Jose Navas; Andres Avalos [50%]; Cuty Monge [50%]; Servicio de Catering [0.6%] | 24h | 1,042 |  |  |
| 79 | 3.7 | Inserción banda sonora final | 9d | 2018-09-27 | 2018-10-10 | 78 | 0d |  | Joel Navas; Oscar Mendez; Cuty Monge | 216h | 4,410 |  |  |
| 80 | 3.8 | Adición de cabeceras y créditos | 1w | 2018-10-10 | 2018-10-17 | 79 | 0d |  | Jose Navas; Oscar Mendez; Laboratorio de edición | 120h | 2,965 |  |  |
| 81 | 3.9 | Adición de banda musical final | 16d | 2018-10-17 | 2018-11-08 | 80 | 0d |  | Oscar Mendez | 128h | 2,624 |  |  |
| 82 | 3.10 | Impresión de negativos | 3d | 2018-11-08 | 2018-11-13 | 81 | 0d |  | Viaticos [0.2%] |  | 572 |  |  |
| 83 | 3.11 | Copia de la banda sonora final | 12d | 2018-11-13 | 2018-11-29 | 82 | 0d |  | Douglas Hernandez [50%] | 48h | 921.6 |  |  |
| 84 | 3.12 | Archivado de imagen y sonido finales | 2d | 2018-11-29 | 2018-12-03 | 83 | 0d |  | Douglas Hernandez [50%]; Laboratorio de edición; Oscar Mendez | 20h | 515.8 |  |  |
| 85 | 3.13 | Entrega al distribuidor | 1d | 2018-12-03 | 2018-12-04 | 84 | 0d |  | Oscar Mendez | 8h | 164 |  |  |
