# Breve proyecto cinematográfico

Schedule from MS Project, 2012-03-03 to 2015-06-08, costs in €, A marks actual dates.
Videos Southridge

## Calendars

- Standard: Mon-Fri 08:00-12:00, 13:00-17:00; Sat-Sun off.
- Evening Shoot: Mon-Fri 17:00-23:00; Sat-Sun off.

## Resources

| Resource | Group | Unit | Rate | Cost per use |
| --- | --- | --- | --- | --- |
| Cámara de 16 mm | Equipo |  | 7.5 |  |
| Película de 16 mm | Laboratorio | 100 metros | 25 |  |
| Foco de 500 watios | Equipo |  | 2.5 |  |
| Anne L. Paper | Creativos |  | 18.75 |  |
| Trípode de cámara | Equipo |  |  |  |
| Clair Hector | Producción |  | 22.5 |  |
| Grúa | Equipo |  |  |  |
| Daniel Penn | Creativos |  | 18.75 |  |
| David Campbell | Creativos |  | 18.75 |  |
| Dolly | Equipo |  |  |  |
| Doug Hampton | Producción |  | 19.2 |  |
| Laboratorio de edición | Laboratorio |  | 31.25 | 25 |
| Electricista | Auxiliares |  | 28 |  |
| Eric Lang | Producción |  | 18.5 |  |
| Eric Miller | Creativos |  | 18.75 |  |
| Florian Voss | Producción |  | 25 |  |
| Frank Lee | Auxiliares |  | 17 |  |
| Jan Miksovsky | Producción |  | 21.75 |  |
| Jim Hance | Creativos |  | 9.38 |  |
| Jo Brown | Producción |  | 21.75 |  |
| Johnathan Perrera | Producción |  | 25 |  |
| Joseph Matthews | Creativos |  | 18.75 |  |
| Joshua Randall | Creativos |  | 16 |  |
| Kathryn Wilson | Producción |  | 20 | 100 |
| Keith Harris | Auxiliares |  | 17 |  |
| Kim Yoshida | Producción |  | 16.4 |  |
| Linda Kobara | Producción |  | 27 |  |
| Lisa Garmaise | Producción |  | 16 |  |
| Mark Hassall | Producción |  | 25 |  |
| Max Benson | Auxiliares |  | 27 |  |
| Megan Sherman | Auxiliares |  | 21 |  |
| Michael Patten | Producción |  | 20.5 |  |
| Pat Kirtland | Producción |  | 15 |  |
| Paul Borm | Producción |  | 28.12 |  |
| Reflector | Equipo |  |  |  |
| Richard Lum | Producción |  | 18.5 |  |
| Salman Mughal | Producción |  | 21 |  |
| Scott Cooper | Producción |  | 22 |  |
| Sue Jackson | Creativos |  | 15 |  |
| Ted Bremer | Auxiliares |  | 18 |  |
| Tim O'Brien | Auxiliares |  | 18 |  |
| Catering | Gastos |  |  |  |
| Viajes | Gastos |  |  |  |

## Schedule

| ID | WBS | Task | Type | Duration | Start | Finish | Predecessors | Complete | Remaining | Total slack | Free slack | Constraint | Deadline | Resources | Work | Actual work | Cost | Actual cost | Personal | Location |
| --- | --- | --- | --- | --- | --- | --- | --- | --- | --- | --- | --- | --- | --- | --- | --- | --- | --- | --- | --- | --- |
| 1 | 1 | **Preproducción** |  | 703d | 2012-03-03 A | 2014-11-12 |  | 92% | 58.62d | 0d |  |  |  |  | 8960h | 7812h | 201,720 | 174,490 |  |  |
| 2 | 1.1 | Revisión del guión literario |  | 650d | 2012-03-03 A | 2014-08-29 A |  | 100% |  |  |  |  |  | Scott Cooper [50%]; Clair Hector | 7792h | 7792h | 174,020 | 174,020 |  |  |
| 3 | 1.2 | División y planificación del guión literario |  | 1w | 2014-08-24 A | 2014-09-04 | 2 | 25% | 0.75w | -1683.12d | 0d |  |  | Scott Cooper; Johnathan Perrera | 80h | 20h | 1,880 | 470 |  |  |
| 4 | 1.3 | Desarrollo del guión técnico |  | 1.07mo | 2014-09-04 | 2014-10-07 | 3 |  |  | -1683.12d | 0d |  |  | Scott Cooper; Kim Yoshida; Johnathan Perrera | 480h |  | 10,144 |  |  |  |
| 5 | 1.4 | Búsqueda de exteriores |  | 2w | 2014-10-08 | 2014-10-21 | 4 |  |  | -1683d | 0d |  |  | Jo Brown; Jan Miksovsky; Max Benson; Viajes [0.1%] | 240h |  | 6,640 |  |  |  |
| 6 | 1.5 | Selección de exteriores |  | 1.05w | 2014-10-22 | 2014-10-29 | 5 |  |  | -1683.12d | 0d |  |  | Scott Cooper; Clair Hector; Max Benson | 120h |  | 2,860 |  |  |  |
| 7 | 1.6 | Realización de pruebas a actores |  | 1.05w | 2014-10-29 | 2014-11-05 | 6 |  |  | -1683.12d | 0d |  |  | Clair Hector; Scott Cooper; Doug Hampton [50%]; Catering [0.1%] | 100h |  | 2,664 |  |  |  |
| 8 | 1.7 | Solicitud de permisos de rodaje |  | 1w | 2014-11-05 | 2014-11-12 | 7 |  |  | -1683.25d | 0d |  |  | Kim Yoshida | 40h |  | 1,156 |  |  |  |
| 9 | 1.8 | Reserva de equipo de rodaje |  | 3d | 2014-11-10 | 2014-11-12 | 8FS-5% |  |  | -1683.12d | 0d |  |  | Jan Miksovsky; Eric Lang [50%] | 36h |  | 744 |  |  |  |
| 10 | 1.9 | Reserva de equipo de sonido |  | 3d | 2014-11-10 | 2014-11-12 | 9SS |  |  | -1683.12d | 0d |  |  | Eric Lang [50%] | 12h |  | 222 |  |  |  |
| 11 | 1.10 | ¡Preproducción completada! | milestone | 0d | 2014-11-12 | 2014-11-12 | 10 |  |  | -1683d | 0d |  | 2008-05-22 |  |  |  |  |  |  |  |
| 12 | 1.11 | **Reunión de seguimiento** |  | 45.25d | 2012-03-12 | 2012-05-14 |  |  |  | 652.62d |  |  |  |  | 60h |  | 1,390 |  |  |  |
| 13 | 1.11.1 | Reunión de seguimiento 1 |  | 2h | 2012-03-12 | 2012-03-12 |  |  |  | 697.62d |  | start no earlier than 2012-03-12 |  | Clair Hector; Johnathan Perrera; Scott Cooper | 6h |  | 139 |  |  |  |
| 14 | 1.11.2 | Reunión de seguimiento 2 |  | 2h | 2012-03-19 | 2012-03-19 |  |  |  | 692.62d |  | start no earlier than 2012-03-19 |  | Clair Hector; Johnathan Perrera; Scott Cooper | 6h |  | 139 |  |  |  |
| 15 | 1.11.3 | Reunión de seguimiento 3 |  | 2h | 2012-03-26 | 2012-03-26 |  |  |  | 687.62d |  | start no earlier than 2012-03-26 |  | Clair Hector; Johnathan Perrera; Scott Cooper | 6h |  | 139 |  |  |  |
| 16 | 1.11.4 | Reunión de seguimiento 4 |  | 2h | 2012-04-02 | 2012-04-02 |  |  |  | 682.62d |  | start no earlier than 2012-04-02 |  | Clair Hector; Johnathan Perrera; Scott Cooper | 6h |  | 139 |  |  |  |
| 17 | 1.11.5 | Reunión de seguimiento 5 |  | 2h | 2012-04-09 | 2012-04-09 |  |  |  | 677.62d |  | start no earlier than 2012-04-09 |  | Clair Hector; Johnathan Perrera; Scott Cooper | 6h |  | 139 |  |  |  |
| 18 | 1.11.6 | Reunión de seguimiento 6 |  | 2h | 2012-04-16 | 2012-04-16 |  |  |  | 672.62d |  | start no earlier than 2012-04-16 |  | Clair Hector; Johnathan Perrera; Scott Cooper | 6h |  | 139 |  |  |  |
| 19 | 1.11.7 | Reunión de seguimiento 7 |  | 2h | 2012-04-23 | 2012-04-23 |  |  |  | 667.62d |  | start no earlier than 2012-04-23 |  | Clair Hector; Johnathan Perrera; Scott Cooper | 6h |  | 139 |  |  |  |
| 20 | 1.11.8 | Reunión de seguimiento 8 |  | 2h | 2012-04-30 | 2012-04-30 |  |  |  | 662.62d |  | start no earlier than 2012-04-30 |  | Clair Hector; Johnathan Perrera; Scott Cooper | 6h |  | 139 |  |  |  |
| 21 | 1.11.9 | Reunión de seguimiento 9 |  | 2h | 2012-05-07 | 2012-05-07 |  |  |  | 657.62d |  | start no earlier than 2012-05-07 |  | Clair Hector; Johnathan Perrera; Scott Cooper | 6h |  | 139 |  |  |  |
| 22 | 1.11.10 | Reunión de seguimiento 10 |  | 2h | 2012-05-14 | 2012-05-14 |  |  |  | 652.62d |  | start no earlier than 2012-05-14 |  | Clair Hector; Johnathan Perrera; Scott Cooper | 6h |  | 139 |  |  |  |
| 23 | 2 | **Producción** |  | 52.38d | 2014-11-13 | 2015-01-26 | 1 |  |  | 0d |  |  |  |  | 2243h |  | 47,058.2 |  |  |  |
| 24 | 2.1 | **Escena 7** |  | 4.88d | 2014-11-13 | 2014-11-19 |  |  |  | 0d |  |  |  |  | 220h |  | 4,718.5 |  |  |  |
| 25 | 2.1.1 | Escena 7: Instalación de decorados |  | 1d | 2014-11-13 | 2014-11-13 |  |  |  | 0d |  |  |  | Jo Brown; Max Benson; Electricista [50%] | 20h |  | 502 |  |  |  |
| 26 | 2.1.2 | Escena 7: Ensayo |  | 1d | 2014-11-14 | 2014-11-14 | 25 |  |  | 0d |  |  |  | Scott Cooper; Jo Brown; Paul Borm [50%]; Joseph Matthews; Sue Jackson; Jan Miksovsky | 44h |  | 906.5 |  |  |  |
| 27 | 2.1.3 | Escena 7: Rodaje |  | 1d | 2014-11-17 | 2014-11-17 | 26 |  |  | 0d |  |  |  | Scott Cooper; Jo Brown; Joseph Matthews; Sue Jackson; Frank Lee; Keith Harris; Ted Bremer; Cámara de 16 mm [300%]; Foco de 500 watios [200%]; Joshua Randall; Megan Sherman; Tim O'Brien; Jan Miksovsky; Trípode de cámara; Película de 16 mm [5 100 metros] | 136h |  | 2,808 |  | Richard, Store clerk #1, Store clerk #2 | Grocery store |
| 28 | 2.1.4 | Escena 7: Montaje |  | 1d | 2014-11-18 | 2014-11-18 | 27 |  |  | 0d |  |  |  | Jo Brown; Max Benson; Electricista [50%] | 20h |  | 502 |  |  |  |
| 29 | 2.1.5 | Escena 7: Reproceso |  | 1d | 2014-11-19 | 2014-11-19 | 28 |  |  | 0.12d |  |  |  |  |  |  |  |  |  |  |

| ID | WBS | Task | Duration | Start | Finish | Predecessors | Total slack | Free slack | Constraint | Calendar | Resources | Work | Cost | Personal | Location |
| --- | --- | --- | --- | --- | --- | --- | --- | --- | --- | --- | --- | --- | --- | --- | --- |
| 30 | 2.2 | **Escena 3** | 4d | 2014-11-19 | 2014-11-25 | 24 | 0.12d | 0d |  |  |  | 268h | 5,330.8 |  |  |
| 31 | 2.2.1 | Escena 3: Instalación de decorados | 1d | 2014-11-19 | 2014-11-20 |  | 0d |  | start no earlier than 2008-05-26 |  | Jo Brown; Max Benson; Electricista | 24h | 614 |  |  |
| 32 | 2.2.2 | Escena 3: Ensayo | 1d | 2014-11-20 | 2014-11-21 | 31 | 0d |  |  |  | Scott Cooper; Jo Brown; Eric Miller; Jim Hance; Anne L. Paper; Joseph Matthews; Jan Miksovsky | 56h | 1,049 |  |  |
| 33 | 2.2.3 | Escena 3: Rodaje | 1d | 2014-11-21 | 2014-11-24 | 32 | 0d |  |  |  | Scott Cooper; Jo Brown; Eric Miller; Jim Hance; Anne L. Paper; Joseph Matthews; Tim O'Brien; Megan Sherman; Doug Hampton [50%]; Keith Harris; Cámara de 16 mm [200%]; Foco de 500 watios [400%]; Dolly; Frank Lee; Jan Miksovsky; Ted Bremer; Trípode de cámara; Película de 16 mm [5 100 metros] | 164h | 3,053.8 | Man on street, Richard | Street corner |
| 34 | 2.2.4 | Escena 3: Montaje | 1d | 2014-11-24 | 2014-11-25 | 33 | 0d |  |  |  | Jo Brown; Max Benson; Electricista | 24h | 614 |  |  |
| 35 | 2.2.5 | Escena 3: Reproceso | 1d | 2014-11-25 | 2014-11-25 | 33 | 0.12d |  |  |  |  |  |  |  |  |
| 36 | 2.3 | **Escena 1** | 6d | 2014-11-25 | 2014-12-03 | 30 | 0.12d | 0d |  |  |  | 324h | 7,469.8 |  |  |
| 37 | 2.3.1 | Escena 1: Instalación de decorados | 3d | 2014-11-25 | 2014-11-28 |  | 0d |  |  |  | Jo Brown; Max Benson; Electricista [200%] | 96h | 2,514 |  |  |
| 38 | 2.3.2 | Escena 1: Ensayo | 1d | 2014-11-28 | 2014-12-01 | 37 | 0d |  |  |  | Scott Cooper; Jo Brown; Paul Borm [50%]; David Campbell; Eric Miller; Sue Jackson; Jan Miksovsky | 52h | 1,056.5 |  |  |
| 39 | 2.3.3 | Escena 1: Rodaje | 1d | 2014-12-01 | 2014-12-02 | 38 | 0d |  |  |  | Scott Cooper; Jo Brown; Paul Borm [50%]; David Campbell; Eric Miller; Sue Jackson; Tim O'Brien; Frank Lee; Megan Sherman; Doug Hampton [50%]; Keith Harris; Ted Bremer; Cámara de 16 mm [300%]; Foco de 500 watios; Jan Miksovsky; Dolly; Trípode de cámara; Película de 16 mm [5 100 metros] | 144h | 3,061.3 | Garth, Man on street, Store clerk #1 | Street corner |
| 40 | 2.3.4 | Escena 1: Montaje | 1d | 2014-12-02 | 2014-12-03 | 39 | 0d |  |  |  | Jo Brown; Max Benson; Electricista [200%] | 32h | 838 |  |  |
| 41 | 2.3.5 | Escena 1: Reproceso | 1d | 2014-12-03 | 2014-12-03 | 39 | 0.12d |  |  |  |  |  |  |  |  |
| 42 | 2.4 | **Escena 2** | 5d | 2014-12-03 | 2014-12-10 | 36 | 0.12d | 0d |  |  |  | 216h | 4,421.6 |  |  |
| 43 | 2.4.1 | Escena 2: Instalación de decorados | 1d | 2014-12-03 | 2014-12-04 |  | 0d |  |  |  | Jo Brown; Max Benson; Electricista | 24h | 614 |  |  |
| 44 | 2.4.2 | Escena 2: Ensayo | 1d | 2014-12-04 | 2014-12-05 | 43 | 0d |  |  |  | Scott Cooper; Doug Hampton [50%]; David Campbell; Anne L. Paper; Jan Miksovsky | 36h | 726.8 |  |  |
| 45 | 2.4.3 | Escena 2: Rodaje | 1d | 2014-12-05 | 2014-12-08 | 44 | 0.5d | 0.12d |  | Evening Shoot | Scott Cooper; Doug Hampton [50%]; Anne L. Paper; Tim O'Brien; Frank Lee; Keith Harris; Ted Bremer; Cámara de 16 mm [200%]; Foco de 500 watios [300%]; Jan Miksovsky; David Campbell; Trípode de cámara; Grúa; Dolly; Película de 16 mm [5 100 metros] | 132h | 2,466.8 | Garth, Shelly | Shelly's living room |
| 46 | 2.4.4 | Escena 2: Montaje | 1d | 2014-12-09 | 2014-12-09 | 45 | 0d |  |  |  | Jo Brown; Max Benson; Electricista | 24h | 614 |  |  |
| 47 | 2.4.5 | Escena 2: Reproceso | 1d | 2014-12-10 | 2014-12-10 | 46 | 0.12d |  |  |  |  |  |  |  |  |
| 48 | 2.5 | **Escena 5** | 6d | 2014-12-10 | 2014-12-18 | 42 | 0.12d | 0d |  |  |  | 288h | 5,925.8 |  |  |
| 49 | 2.5.1 | Escena 5: Instalación de decorados | 3d | 2014-12-10 | 2014-12-15 |  | 0d |  |  |  | Jo Brown; Max Benson | 48h | 1,170 |  |  |
| 50 | 2.5.2 | Escena 5: Ensayo | 1d | 2014-12-15 | 2014-12-16 | 49 | 0d |  |  |  | Scott Cooper; Jo Brown; Eric Miller; David Campbell; Sue Jackson; Daniel Penn; Anne L. Paper; Jan Miksovsky [50%] | 60h | 1,157 |  |  |
| 51 | 2.5.3 | Escena 5: Rodaje | 1d | 2014-12-16 | 2014-12-17 | 50 | 0d |  |  |  | Scott Cooper; Jo Brown; Eric Miller; David Campbell; Sue Jackson; Daniel Penn; Anne L. Paper; Tim O'Brien; Frank Lee; Megan Sherman; Doug Hampton [50%]; Keith Harris; Ted Bremer; Cámara de 16 mm [200%]; Foco de 500 watios [200%]; Grúa; Jan Miksovsky; Trípode de cámara; Dolly; Película de 16 mm [5 100 metros] | 164h | 3,208.8 | Man on street, Garth, Old man, Shelly | Street corner |
| 52 | 2.5.4 | Escena 5: Montaje | 1d | 2014-12-17 | 2014-12-18 | 51 | 0d |  |  |  | Jo Brown; Max Benson | 16h | 390 |  |  |
| 53 | 2.5.5 | Escena 5: Reproceso | 1d | 2014-12-18 | 2014-12-18 | 51 | 0.12d |  |  |  |  |  |  |  |  |

| ID | WBS | Task | Duration | Start | Finish | Predecessors | Total slack | Free slack | Resources | Work | Cost | Personal | Location |
| --- | --- | --- | --- | --- | --- | --- | --- | --- | --- | --- | --- | --- | --- |
| 54 | 2.6 | **Escena 6** | 14d | 2014-12-18 | 2015-01-07 | 48 | 0.12d | 0d |  | 524h | 10,604.2 |  |  |
| 55 | 2.6.1 | Escena 6: Instalación de decorados | 6d | 2014-12-18 | 2014-12-26 |  | 0d |  | Jo Brown; Max Benson | 96h | 2,340 |  |  |
| 56 | 2.6.2 | Escena 6: Ensayo | 3d | 2014-12-26 | 2014-12-31 | 55 | 0d |  | Scott Cooper; Jo Brown; Doug Hampton [50%]; Paul Borm [50%]; David Campbell; Sue Jackson; Anne L. Paper; Jim Hance; Daniel Penn; Jan Miksovsky [50%] | 204h | 3,813.9 |  |  |
| 57 | 2.6.3 | Escena 6: Rodaje | 1d | 2014-12-31 | 2015-01-01 | 56 | 0d |  | Scott Cooper; Jo Brown; Doug Hampton [50%]; Paul Borm [50%]; David Campbell; Sue Jackson; Anne L. Paper; Jim Hance; Daniel Penn; Frank Lee; Megan Sherman; Keith Harris; Ted Bremer; Cámara de 16 mm [300%]; Foco de 500 watios [300%]; Dolly; Grúa; Joshua Randall; Tim O'Brien; Película de 16 mm [5 100 metros] | 176h | 3,280.3 | Garth, Store Clerk #1, Shelly, Old man | Grocery store |
| 58 | 2.6.4 | Escena 6: Montaje | 3d | 2015-01-01 | 2015-01-06 | 57 | 0d |  | Jo Brown; Max Benson | 48h | 1,170 |  |  |
| 59 | 2.6.5 | Escena 6: Reproceso | 1d | 2015-01-07 | 2015-01-07 | 58 | 0.12d |  |  |  |  |  |  |
| 60 | 2.7 | **Escena 8** | 8d | 2015-01-07 | 2015-01-19 | 54 | 0d |  |  | 312h | 6,479.9 |  |  |
| 61 | 2.7.1 | Escena 8: Instalación de decorados | 3d | 2015-01-07 | 2015-01-12 |  | 0d |  | Jo Brown; Max Benson | 48h | 1,170 |  |  |
| 62 | 2.7.2 | Escena 8: Ensayo | 2d | 2015-01-12 | 2015-01-14 | 61 | 0d |  | Scott Cooper; Jo Brown; Doug Hampton [50%]; Paul Borm [50%]; David Campbell; Sue Jackson; Eric Miller; Jan Miksovsky [50%] | 104h | 2,092.6 |  |  |
| 63 | 2.7.3 | Escena 8: Rodaje | 1d | 2015-01-14 | 2015-01-15 | 62 | 0d |  | Scott Cooper; Jo Brown; Doug Hampton [50%]; Paul Borm [50%]; David Campbell; Sue Jackson; Eric Miller; Tim O'Brien; Frank Lee; Megan Sherman; Keith Harris; Ted Bremer; Cámara de 16 mm [200%]; Foco de 500 watios; Dolly [200%]; Trípode de cámara; Grúa; Película de 16 mm [5 100 metros] | 144h | 2,827.3 | Garth, Store clerk #1, Man on street | Street corner |
| 64 | 2.7.4 | Escena 8: Montaje | 1d | 2015-01-15 | 2015-01-16 | 63 | 0d |  | Jo Brown; Max Benson | 16h | 390 |  |  |
| 65 | 2.7.5 | Escena 8: Reproceso | 1d | 2015-01-19 | 2015-01-19 | 64 | 0d |  |  |  |  |  |  |
| 66 | 2.8 | **Escena 4** | 4.5d | 2015-01-19 | 2015-01-26 | 60 | 0d |  |  | 91h | 2,107.6 |  |  |
| 67 | 2.8.1 | Escena 4: Instalación de decorados | 2d | 2015-01-19 | 2015-01-21 |  | 0d |  | Jo Brown; Max Benson | 32h | 780 |  |  |
| 68 | 2.8.2 | Escena 4: Ensayo | 4h | 2015-01-21 | 2015-01-22 | 67 | 0d |  | Scott Cooper; Doug Hampton [50%]; Anne L. Paper; Joseph Matthews; Jan Miksovsky [50%] | 16h | 319.9 |  |  |
| 69 | 2.8.3 | Escena 4: Rodaje | 2h | 2015-01-22 | 2015-01-22 | 68 | 0d |  | Scott Cooper; Doug Hampton [50%]; Anne L. Paper; Joseph Matthews; Frank Lee; Megan Sherman; Keith Harris; Cámara de 16 mm [200%]; Foco de 500 watios [200%]; Jan Miksovsky; Ted Bremer; Trípode de cámara; Película de 16 mm [5 100 metros] | 27h | 617.7 | Shelly, Richard | Elevator |
| 70 | 2.8.4 | Escena 4: Montaje | 1d | 2015-01-22 | 2015-01-23 | 69 | 0d |  | Jo Brown; Max Benson | 16h | 390 |  |  |
| 71 | 2.8.5 | Escena 4: Reproceso | 1d | 2015-01-23 | 2015-01-26 | 70 | 0.25d |  |  |  |  |  |  |
| 72 | 3 | **Post-producción** | 95.38d | 2015-01-26 | 2015-06-08 | 23 | 0d |  |  | 1628h | 36,662.4 |  |  |
| 73 | 3.1 | Ajustes previos | 9d | 2015-01-26 | 2015-02-06 |  | 0.25d | 0d | Laboratorio de edición; Viajes [0.2%] | 72h | 3,771 |  |  |
| 74 | 3.2 | Grabación BS previa | 12d | 2015-02-06 | 2015-02-24 | 73 | 0d |  | David Campbell; Michael Patten | 192h | 3,768 |  |  |
| 75 | 3.3 | Edición en papel | 10d | 2015-02-24 | 2015-03-10 | 74 | 0d |  | Clair Hector; Kim Yoshida; Lisa Garmaise; Richard Lum | 320h | 5,872 |  |  |
| 76 | 3.4 | Primera edición | 5d | 2015-03-10 | 2015-03-17 | 75 | 0d |  | Clair Hector; Richard Lum | 80h | 1,640 |  |  |
| 77 | 3.5 | Ajustes en la edición | 10d | 2015-03-17 | 2015-03-31 | 76 | 0d |  | Clair Hector; Richard Lum; Lisa Garmaise; Kim Yoshida; Laboratorio de edición | 400h | 8,397 |  |  |
| 78 | 3.6 | Presentación a cliente | 1d | 2015-03-31 | 2015-04-01 | 77 | 0.25d | 0d | Clair Hector; Jo Brown; Mark Hassall [50%]; Scott Cooper [50%]; Catering [0.6%] | 24h | 1,042 |  |  |
| 79 | 3.7 | Inserción banda sonora final | 9d | 2015-04-01 | 2015-04-14 | 78 | 0d |  | David Campbell; Michael Patten; Scott Cooper | 216h | 4,410 |  |  |
| 80 | 3.8 | Adición de cabeceras y créditos | 1w | 2015-04-14 | 2015-04-21 | 79 | 0d |  | Jo Brown; Michael Patten; Laboratorio de edición | 120h | 2,965 |  |  |
| 81 | 3.9 | Adición de banda musical final | 16d | 2015-04-21 | 2015-05-13 | 80 | 0d |  | Michael Patten | 128h | 2,624 |  |  |
| 82 | 3.10 | Impresión de negativos | 3d | 2015-05-13 | 2015-05-18 | 81 | 0d |  | Viajes [0.2%] |  | 572 |  |  |
| 83 | 3.11 | Copia de la banda sonora final | 12d | 2015-05-18 | 2015-06-03 | 82 | 0d |  | Doug Hampton [50%] | 48h | 921.6 |  |  |
| 84 | 3.12 | Archivado de imagen y sonido finales | 2d | 2015-06-03 | 2015-06-05 | 83 | 0d |  | Doug Hampton [50%]; Laboratorio de edición; Michael Patten | 20h | 515.8 |  |  |
| 85 | 3.13 | Entrega al distribuidor | 1d | 2015-06-05 | 2015-06-08 | 84 | 0d |  | Michael Patten | 8h | 164 |  |  |
